# CSF Upgrades and Migrations

Schedule from MS Project, 2013-01-14 to 2013-08-01, A marks actual dates.
MIT

## Calendars

- Standard: Mon-Fri 08:00-12:00, 13:00-17:00; Sat-Sun off.

## Resources

| Resource |
| --- |
| Dave |
| René |
| Steve |
| Felicia |
| Ram |
| Kevin |
| Brian |
| Janet |
| Seth |
| Lee |
| Faith |
| Peter |
| Debra |
| Frank Q. |
| Jack |

## Schedule

| ID | WBS | Task | Type | Duration | Start | Finish | Predecessors | Complete | Baseline start | Baseline finish | Baseline duration | Resources | Work | Actual work |
| --- | --- | --- | --- | --- | --- | --- | --- | --- | --- | --- | --- | --- | --- | --- |
| 1 | 1 | Upgrade CSF to 2.0 |  | 10d | 2013-01-14 A | 2013-01-25 A |  | 100% |  |  |  |  |  |  |
| 2 | 2 | **Upgrade of Existing CSF Apps to CSF 2.0** |  | 46d | 2013-02-13 A | 2013-04-17 A |  | 100% | 2013-02-13 | 2013-03-08 | 18d? |  | 257.6h | 257.6h |
| 3 | 2.1 | **Development** |  | 11d | 2013-02-13 A | 2013-02-27 A |  | 100% | 2013-02-13 | 2013-03-08 | 18d |  | 64h | 64h |
| 4 | 2.1.1 | Upgrade IAP |  | 7d | 2013-02-14 A | 2013-02-25 A | 1FS+13d | 100% | 2013-02-14 | 2013-02-20 | 4d | Steve [50%] | 28h | 28h |
| 5 | 2.1.2 | Upgrade Subject Evaluation Report/OSE Report |  | 1d | 2013-02-26 A | 2013-02-26 A | 4FS+3d | 100% | 2013-02-26 | 2013-03-01 | 4d | Steve [50%] | 4h | 4h |
| 6 | 2.1.3 | Upgrade Sponsor Billing |  | 4d | 2013-02-13 A | 2013-02-19 A | 1FS+12d | 100% | 2013-02-13 | 2013-02-19 | 4d | Dave [50%] | 16h | 16h |
| 7 | 2.1.4 | Upgrade Survey Engine |  | 2d | 2013-02-26 A | 2013-02-27 A | 6FS+4d | 100% | 2013-02-26 | 2013-03-01 | 4d | Dave [50%] | 8h | 8h |
| 8 | 2.1.5 | Upgrade Response Rate Report |  | 2d | 2013-02-22 A | 2013-02-25 A | 7FS+1d | 100% | 2013-03-05 | 2013-03-08 | 4d | Dave [50%] | 8h | 8h |
| 9 | 2.1.6 | Upgrades complete | milestone | 0d | 2013-02-27 A | 2013-02-27 A | 4, 5, 6, 7, 8 | 100% | 2013-03-08 | 2013-03-08 | 0d | Dave [50%]; Steve [50%] |  |  |
| 10 | 2.2 | **Testing** |  | 30d | 2013-02-20 A | 2013-04-02 A |  | 100% |  |  |  |  | 113.6h | 113.6h |
| 11 | 2.2.1 | **Test Planning** |  | 8d | 2013-02-20 A | 2013-03-01 A |  | 100% |  |  |  |  | 31.6h | 31.6h |
| 12 | 2.2.1.1 | Sponsor Billing |  | 3d | 2013-02-20 A | 2013-02-22 A | 4SS+4d | 100% |  |  |  | Seth [25%]; Faith [25%] | 7.6h | 7.6h |
| 13 | 2.2.1.2 | OSE Applications |  | 3d | 2013-02-27 A | 2013-03-01 A | 12FS+2d | 100% |  |  |  | Lee | 24h | 24h |
| 14 | 2.2.1.3 | Test Planning Complete | milestone | 0d | 2013-03-01 A | 2013-03-01 A | 12, 13 | 100% |  |  |  |  |  |  |
| 15 | 2.2.2 | **BA Testing** |  | 27d | 2013-02-25 A | 2013-04-02 A |  | 100% |  |  |  |  | 82h | 82h |
| 16 | 2.2.2.1 | Sponsor Billing |  | 3d | 2013-02-25 A | 2013-02-27 A | 12 | 100% |  |  |  | Faith [25%] | 6h | 6h |
| 17 | 2.2.2.2 | IAP (includes planning) |  | 22d | 2013-03-04 A | 2013-04-02 A | 16FS+2d | 100% |  |  |  | Seth [25%] | 44h | 44h |
| 18 | 2.2.2.3 | OSE Applications |  | 4d | 2013-03-04 A | 2013-03-07 A | 13 | 100% |  |  |  | Lee | 32h | 32h |
| 19 | 2.2.2.4 | BA Testing Complete | milestone | 0d | 2013-03-28 A | 2013-03-28 A | 16, 18, 17 | 100% |  |  |  |  |  |  |
| 20 | 2.2.3 | **UAT** |  | 4d | 2013-03-04 A | 2013-03-07 A |  | 100% |  |  |  |  |  |  |
| 21 | 2.2.3.1 | OSE Applications |  | 4d | 2013-03-04 A | 2013-03-07 A | 18SS | 100% |  |  |  |  |  |  |
| 22 | 2.2.3.2 | UAT Complete | milestone | 0d | 2013-03-07 A | 2013-03-07 A | 21 | 100% |  |  |  |  |  |  |
| 23 | 2.2.4 | Testing Efforts Complete | milestone | 0d | 2013-03-28 A | 2013-03-28 A | 14, 19, 22 | 100% |  |  |  |  |  |  |
| 24 | 2.3 | **Deployment Preparation** |  | 11d | 2013-04-03 A | 2013-04-17 A |  | 100% |  |  |  |  | 80h | 80h |
| 25 | 2.3.1 | Get business approval for IAP |  | 10d | 2013-04-03 A | 2013-04-17 A | 17 | 100% |  |  |  | Seth | 80h | 80h |

| ID | WBS | Task | Type | Duration | Start | Finish | Predecessors | Complete | Remaining | Total slack | Free slack | Constraint | Resources | Work | Actual work |
| --- | --- | --- | --- | --- | --- | --- | --- | --- | --- | --- | --- | --- | --- | --- | --- |
| 26 | 2.4 | **Go-live** |  | 35d | 2013-02-28 A | 2013-04-17 A |  | 100% |  |  |  |  |  |  |  |
| 27 | 2.4.1 | Sponsor Billing |  | 1d | 2013-02-28 A | 2013-02-28 A | 16FS+2d | 100% |  |  |  |  |  |  |  |
| 28 | 2.4.2 | IAP | milestone | 0d | 2013-04-17 A | 2013-04-17 A | 17FS+2d, 25 | 100% |  |  |  |  |  |  |  |
| 29 | 2.4.3 | OSE Applications |  | 1d | 2013-03-07 A | 2013-03-08 A | 18, 21 | 100% |  |  |  |  |  |  |  |
| 30 | 2.5 | Upgrade of Existing CSF Apps to CSF 2.0 Complete | milestone | 0d | 2013-04-17 A | 2013-04-17 A | 27, 28, 29 | 100% |  |  |  |  |  |  |  |
| 31 | 3 | **Convert SAIS-Common Apps to CSF 2.0** |  | 79d? | 2013-03-22 A | 2013-07-10 |  | 45% | 43.66d? | 16d |  |  |  | 167.04h | 68h |
| 32 | 3.1 | **Batch Admin** |  | 40d | 2013-03-22 A | 2013-05-16 A |  | 100% |  |  |  |  |  | 68h | 68h |
| 33 | 3.1.1 | Development |  | 23d | 2013-03-22 A | 2013-04-24 A |  | 100% |  |  |  |  | Steve [25%] | 46h | 46h |
| 34 | 3.1.2 | Do file comparison |  | 2d | 2013-04-25 A | 2013-04-26 A | 33 | 100% |  |  |  |  | Steve [25%] | 4h | 4h |
| 35 | 3.1.3 | Do SAP testing - iteration 1 |  | 1d | 2013-05-03 A | 2013-05-03 A | 34FS+5d | 100% |  |  |  |  | Frank Q. [25%] | 2h | 2h |
| 36 | 3.1.4 | **Deployment Preparation** |  | 7d | 2013-05-06 A | 2013-05-14 A |  | 100% |  |  |  |  |  | 16h | 16h |
| 37 | 3.1.4.1 | Get business approval |  | 1d | 2013-05-06 A | 2013-05-06 A | 35 | 100% |  |  |  |  | René [25%] | 2h | 2h |
| 38 | 3.1.4.2 | Create deployment plan |  | 7d | 2013-05-06 A | 2013-05-14 A | 35 | 100% |  |  |  |  | René [25%] | 14h | 14h |
| 39 | 3.1.5 | Go-live | milestone | 0d | 2013-05-16 A | 2013-05-16 A | 38FS+2d | 100% |  |  |  |  |  |  |  |
| 40 | 3.2 | **Bundle 1 (Advisor Assignment, Instructor Assignment, Supervisor Assignment, and Reg Control List)** |  | 32d? | 2013-05-28 | 2013-07-10 |  |  |  | 15d |  |  |  | 99.04h |  |
| 41 | 3.2.1 | **Development** |  | 27d | 2013-05-28 | 2013-07-03 |  |  |  | 15d |  |  |  | 95.04h |  |
| 42 | 3.2.1.1 | Convert Advisor Assignment |  | 9d | 2013-05-28 | 2013-06-07 |  |  |  | 15d | 0d | start no earlier than 2013-05-28 | Dave [33%] | 23.76h |  |
| 43 | 3.2.1.2 | Convert Supervisor Assignment |  | 9d | 2013-06-10 | 2013-06-20 | 42 |  |  | 15d | 0d |  | Dave [33%] | 23.76h |  |
| 44 | 3.2.1.3 | Convert Instructor Assignment |  | 9d | 2013-06-21 | 2013-07-03 | 43 |  |  | 16d | 0d |  | Dave [33%] | 23.76h |  |
| 45 | 3.2.1.4 | Convert Reg Control List |  | 9d | 2013-05-28 | 2013-06-07 | 42SS |  |  | 18d |  |  | Steve [33%] | 23.76h |  |
| 46 | 3.2.1.5 | Bundle 1 development complete | milestone | 0d | 2013-07-03 | 2013-07-03 | 44, 45 |  |  | 16d | 0d |  |  |  |  |
| 47 | 3.2.2 | **Testing** |  | 2d? | 2013-07-04 | 2013-07-05 |  |  |  | 16d |  |  |  | 4h |  |
| 48 | 3.2.2.1 | Regression Testing |  | 1d? | 2013-07-04 | 2013-07-04 | 46 |  |  | 16d | 0d |  | Jack [50%] | 4h |  |
| 49 | 3.2.2.2 | Load testing |  | 1d? | 2013-07-05 | 2013-07-05 | 48 |  |  | 2d | 0d |  |  |  |  |
| 50 | 3.2.2.3 | User Testing |  | 1d? | 2013-07-05 | 2013-07-05 | 48 |  |  | 16d | 0d |  |  |  |  |
| 51 | 3.2.2.4 | Testing complete | milestone | 0d | 2013-07-05 | 2013-07-05 | 49, 50 |  |  | 2d |  |  |  |  |  |

| ID | WBS | Task | Duration | Start | Finish | Predecessors | Complete | Remaining | Baseline start | Baseline finish | Baseline duration | Total slack | Free slack | Constraint | Resources | Work | Actual work |
| --- | --- | --- | --- | --- | --- | --- | --- | --- | --- | --- | --- | --- | --- | --- | --- | --- | --- |
| 52 | 3.2.3 | **Deployment Preparation** | 2d? | 2013-07-08 | 2013-07-09 |  |  |  |  |  |  | 16d |  |  |  |  |  |
| 53 | 3.2.3.1 | Create deployment plan | 1d? | 2013-07-08 | 2013-07-08 | 50 |  |  |  |  |  | 16d | 0d |  |  |  |  |
| 54 | 3.2.3.2 | Review deployment plan with participants | 1d? | 2013-07-09 | 2013-07-09 | 53 |  |  |  |  |  | 16d | 0d |  |  |  |  |
| 55 | 3.2.4 | Go-live | 1d? | 2013-07-10 | 2013-07-10 | 51, 54 |  |  |  |  |  | 16d |  |  |  |  |  |
| 56 | 4 | **PE REG Upgrade** | 144d? | 2013-01-14 A | 2013-08-01 |  | 46% | 77.25d? | 2013-02-07 | 2013-03-07 | 21d? | 0d |  |  |  | 442h | 298h |
| 57 | 4.1 | **Phase I - Java 6, Touchstone, and CSF Enabling** | 54d | 2013-02-07 A | 2013-04-23 A |  | 100% |  | 2013-02-07 | 2013-03-07 | 21d? |  |  |  |  | 298h | 298h |
| 58 | 4.1.1 | **Development** | 27d | 2013-02-07 A | 2013-03-15 A |  | 100% |  | 2013-02-07 | 2013-03-07 | 21d |  |  |  |  | 208h | 208h |
| 59 | 4.1.1.1 | Do set-up and configuration required for upgrade | 5d | 2013-02-07 A | 2013-02-13 A |  | 100% |  | 2013-02-07 | 2013-02-13 | 5d |  |  |  | Ram | 40h | 40h |
| 60 | 4.1.1.2 | Perform upgrade | 9d | 2013-02-14 A | 2013-02-27 A | 59 | 100% |  | 2013-02-14 | 2013-02-21 | 5d |  |  |  | Ram | 72h | 72h |
| 61 | 4.1.1.3 | Unit test changes | 12d | 2013-02-28 A | 2013-03-15 A | 60 | 100% |  | 2013-02-22 | 2013-03-07 | 10d |  |  |  | Ram | 96h | 96h |
| 62 | 4.1.2 | **Testing** | 45d | 2013-02-20 A | 2013-04-23 A |  | 100% |  |  |  |  |  |  |  |  | 58h | 58h |
| 63 | 4.1.2.1 | Test planning | 12d | 2013-02-20 A | 2013-03-07 A | 60SS+4d | 100% |  |  |  |  |  |  |  | Debra [25%] | 24h | 24h |
| 64 | 4.1.2.2 | QA testing | 12d | 2013-03-18 A | 2013-04-02 A | 63, 61 | 100% |  |  |  |  |  |  |  | Debra [25%] | 24h | 24h |
| 65 | 4.1.2.3 | Load testing | 5d | 2013-04-04 A | 2013-04-10 A | 64FS+1d | 100% |  |  |  |  |  |  |  | Steve [25%] | 10h | 10h |
| 66 | 4.1.2.4 | User testing | 11d | 2013-04-09 A | 2013-04-23 A | 64FS+4d | 100% |  |  |  |  |  |  |  |  |  |  |
| 67 | 4.1.3 | **Deployment Preparation** | 4d | 2013-04-16 A | 2013-04-19 A |  | 100% |  |  |  |  |  |  |  |  | 32h | 32h |
| 68 | 4.1.3.1 | Create deployment plan | 4d | 2013-04-16 A | 2013-04-19 A | 66SS | 100% |  |  |  |  |  |  |  | René | 32h | 32h |
| 69 | 4.2 | **Optimization** | 144d? | 2013-01-14 | 2013-08-01 |  |  |  |  |  |  | 0d |  |  |  | 144h |  |
| 70 | 4.2.1 | Perform analysis/solution design | 20d | 2013-05-13 | 2013-06-07 |  |  |  |  |  |  | 0d |  | start no earlier than 2013-05-13 |  |  |  |
| 71 | 4.2.2 | Make coding changes | 10d | 2013-06-10 | 2013-06-21 | 70 |  |  |  |  |  | 0d |  |  |  |  |  |
| 72 | 4.2.3 | Do SIT | 15d | 2013-06-24 | 2013-07-12 | 71 |  |  |  |  |  | 0d |  |  |  |  |  |
| 73 | 4.2.4 | Do UAT | 14d | 2013-07-15 | 2013-08-01 | 72 |  |  |  |  |  | 0d |  |  |  |  |  |
| 74 | 4.2.5 | **Deployment Prepration** | 5d | 2013-07-22 | 2013-07-26 |  |  |  |  |  |  | 3d |  |  |  | 40h |  |
| 75 | 4.2.5.1 | Review deployment plan with participants | 5d | 2013-07-22 | 2013-07-26 | 73SS+5d |  |  |  |  |  | 3d | 0d |  | René | 40h |  |
| 76 | 4.2.6 | Go-live | 1d? | 2013-07-29 | 2013-07-29 | 75 |  |  |  |  |  | 3d |  |  |  |  |  |

| ID | WBS | Task | Type | Duration | Start | Finish | Predecessors | Complete | Remaining | Baseline start | Baseline finish | Baseline duration | Total slack | Free slack | Constraint | Resources | Work | Actual work |
| --- | --- | --- | --- | --- | --- | --- | --- | --- | --- | --- | --- | --- | --- | --- | --- | --- | --- | --- |
| 77 | 4.2.7 | **Phase II - Full CSF Upgrade** |  | 47d? | 2013-01-14 | 2013-03-19 |  |  |  |  |  |  | 97d |  |  |  | 104h |  |
| 78 | 4.2.7.1 | **Development** |  | 2d? | 2013-03-18 | 2013-03-19 |  |  |  |  |  |  | 97d |  |  |  | 16h |  |
| 79 | 4.2.7.1.1 | Perform full upgrade |  | 1d? | 2013-03-18 | 2013-03-18 | 61 |  |  |  |  |  | 97d | 0d |  | Ram | 8h |  |
| 80 | 4.2.7.1.2 | Unit test changes |  | 1d? | 2013-03-19 | 2013-03-19 | 79 |  |  |  |  |  | 97d |  |  | Ram | 8h |  |
| 81 | 4.2.7.2 | **Testing** |  | 1d? | 2013-01-14 | 2013-01-14 |  |  |  |  |  |  | 143d |  |  |  |  |  |
| 82 | 4.2.7.2.1 | QA |  | 1d? | 2013-01-14 | 2013-01-14 |  |  |  |  |  |  | 143d |  |  |  |  |  |
| 83 | 4.2.7.2.2 | User |  | 1d? | 2013-01-14 | 2013-01-14 |  |  |  |  |  |  | 143d | 11d |  |  |  |  |
| 84 | 4.2.7.3 | **Deployment Preparation** |  | 12d | 2013-01-14 | 2013-01-29 |  |  |  |  |  |  | 132d |  |  |  | 88h |  |
| 85 | 4.2.7.3.1 | Create deployment plan |  | 10d | 2013-01-14 | 2013-01-28 |  |  |  |  |  |  | 132d | 0d |  | René | 80h |  |
| 86 | 4.2.7.3.2 | Review deployment plan with participants |  | 1d | 2013-01-29 | 2013-01-29 | 85 |  |  |  |  |  | 132d | 0d |  | René | 8h |  |
| 87 | 4.2.7.4 | Go-live |  | 1d? | 2013-01-14 | 2013-01-14 |  |  |  |  |  |  | 143d |  |  |  |  |  |
| 88 | 4.2.8 | PE REG upgrade complete | milestone | 0d | 2013-01-29 | 2013-01-29 | 83, 86 |  |  |  |  |  | 132d |  |  | Ram |  |  |
| 89 | 5 | **OREG to Conversion to CSF 2.0** |  | 90d | 2013-02-11 A | 2013-06-14 |  | 79% | 18.82d | 2013-02-11 | 2013-05-28 | 76d | 34d |  |  |  | 790h | 618h |
| 90 | 5.1 | **Development (including unit testing)** |  | 37d | 2013-02-11 A | 2013-04-02 A |  | 100% |  | 2013-02-11 | 2013-03-22 | 29d |  |  |  |  | 400h | 400h |
| 91 | 5.1.1 | Phase 1 - Required as-is , high priority (A/D and OREG) |  | 9d | 2013-02-11 A | 2013-02-22 A |  | 100% |  |  |  |  |  |  | start no earlier than 2013-02-11 | Felicia | 72h | 72h |
| 92 | 5.1.2 | Phase 2 - Medium priority validation and messaging |  | 18d | 2013-02-25 A | 2013-03-20 A | 91 | 100% |  |  |  |  |  |  |  | Felicia | 144h | 144h |
| 93 | 5.1.3 | Phase 3 - Stabilize JAR and rafactor CSF dependencies |  | 8d | 2013-03-13 A | 2013-03-22 A | 92FS-6d | 100% |  |  |  |  |  |  |  | Felicia | 64h | 64h |
| 94 | 5.1.4 | Phase 4 - Modify OREG to use new JAR and upgrade to CSF 2.0 |  | 15d | 2013-03-13 A | 2013-04-02 A | 93SS | 100% |  |  |  |  |  |  |  | Felicia | 120h | 120h |
| 95 | 5.1.5 | OREG conversion development complete | milestone | 0d | 2013-04-02 A | 2013-04-02 A | 94 | 100% |  |  |  |  |  |  |  | Felicia |  |  |
| 96 | 5.2 | Regression Testing |  | 24d | 2013-04-01 A | 2013-05-03 A | 95FS-2d | 100% |  | 2013-03-25 | 2013-04-26 | 24d |  |  |  | Kevin | 192h | 192h |
| 97 | 5.3 | UAT |  | 15d | 2013-04-29 A | 2013-05-17 | 96FS-5d | 87% | 2d | 2013-04-29 | 2013-05-24 | 20d | 52d | 0d |  | Peter [25%] | 30h | 26h |
| 98 | 5.4 | **Deployment Preparation** |  | 11d | 2013-04-29 | 2013-05-13 |  |  |  |  |  |  | 58d |  |  |  | 88h |  |
| 99 | 5.4.1 | Create deployment plan |  | 5d | 2013-04-29 | 2013-05-03 | 97SS |  |  |  |  |  | 58d | 0d |  | René | 40h |  |
| 100 | 5.4.2 | Review deployment plan with participants |  | 1d | 2013-05-06 | 2013-05-06 | 99 |  |  |  |  |  | 58d | 0d |  | René | 8h |  |
| 101 | 5.4.3 | Create registration support plan |  | 5d | 2013-05-07 | 2013-05-13 | 100 |  |  |  |  |  | 58d |  |  | René | 40h |  |
| 102 | 5.5 | Go-live | milestone | 0d | 2013-05-21 | 2013-05-21 | 97FS+2d |  |  | 2013-05-28 | 2013-05-28 | 0d | 52d | 0d |  | René |  |  |
| 103 | 5.6 | Prod smoke test | milestone | 0d | 2013-05-21 | 2013-05-21 | 102 |  |  |  |  |  | 52d |  |  | Peter |  |  |
| 104 | 5.7 | Registration opens | milestone | 0d | 2013-06-03 | 2013-06-03 |  |  |  |  |  |  | 34d | 0d | start no earlier than 2013-06-03 | Peter |  |  |
| 105 | 5.8 | Registration support |  | 10d | 2013-06-03 | 2013-06-14 | 104 |  |  |  |  |  | 34d |  |  | René | 80h |  |

| ID | WBS | Task | Type | Duration | Start | Finish | Predecessors | Complete | Remaining | Total slack | Free slack | Constraint | Resources | Work | Actual work |
| --- | --- | --- | --- | --- | --- | --- | --- | --- | --- | --- | --- | --- | --- | --- | --- |
| 106 | 6 | **Notes Utility Beta** |  | 80d | 2013-02-25 A | 2013-06-14 |  | 87% | 10.08d | 34d |  |  |  | 666h | 582h |
| 107 | 6.1 | **Functional Specs** |  | 26.25d | 2013-02-25 A | 2013-04-02 A |  | 100% |  |  |  |  |  | 178h | 178h |
| 108 | 6.1.1 | Write functional specs |  | 17d | 2013-02-25 A | 2013-03-19 A |  | 100% |  |  |  |  | Seth | 136h | 136h |
| 109 | 6.1.2 | Have team review of functional specs |  | 0.25d | 2013-03-22 A | 2013-03-22 A | 108FS+2d | 100% |  |  |  |  | Seth | 2h | 2h |
| 110 | 6.1.3 | Get sponsor approval on functional spec |  | 5d | 2013-03-26 A | 2013-04-02 A | 109FS+2d | 100% |  |  |  |  | René | 40h | 40h |
| 111 | 6.1.4 | Functional specs complete | milestone | 0d | 2013-04-02 A | 2013-04-02 A | 110 | 100% |  |  |  |  | Seth |  |  |
| 112 | 6.2 | Development |  | 26d | 2013-04-03 A | 2013-05-09 A | 90, 111 | 100% |  |  |  |  | Felicia | 208h | 208h |
| 113 | 6.3 | IS&T validate notes on desktop |  | 1d | 2013-04-29 A | 2013-04-29 A | 112 | 100% |  |  |  |  | René [25%] | 2h | 2h |
| 114 | 6.4 | UAT |  | 15d | 2013-04-29 A | 2013-05-17 | 113SS | 87% | 2d | 52d | 0d |  | Peter [25%] | 30h | 26h |
| 115 | 6.5 | **Deployment Preparation** |  | 12d | 2013-04-29 A | 2013-05-14 A |  | 100% |  |  |  |  |  | 168h | 168h |
| 116 | 6.5.1 | Create deployment plan |  | 10d | 2013-04-29 A | 2013-05-10 A | 99SS | 100% |  |  |  |  | René | 80h | 80h |
| 117 | 6.5.2 | Review deployment plan with participants |  | 1d | 2013-05-14 A | 2013-05-14 A | 116 | 100% |  |  |  |  | René | 8h | 8h |
| 118 | 6.5.3 | Create registration support plan |  | 10d | 2013-05-01 A | 2013-05-14 A | 116SS+2d | 100% |  |  |  |  | René | 80h | 80h |
| 119 | 6.6 | Go-live | milestone | 0d | 2013-05-21 | 2013-05-21 | 114FS+2d |  |  | 52d | 0d |  | René |  |  |
| 120 | 6.7 | Prod smoke test | milestone | 0d | 2013-05-21 | 2013-05-21 | 119 |  |  | 52d |  |  | Peter |  |  |
| 121 | 6.8 | Registration opens | milestone | 0d | 2013-06-03 | 2013-06-03 |  |  |  | 34d | 0d | start no earlier than 2013-06-03 | Peter |  |  |
| 122 | 6.9 | Registration support |  | 10d | 2013-06-03 | 2013-06-14 | 121 |  |  | 34d |  |  | René | 80h |  |

Notes:
- 113: Make sure a non-author can't access notes by manually entering in page(s) notes appear on (Subject Selection and Summary)
